# Narbacular Drop Outline

Schedule from MS Project, 2004-10-11 to 2005-04-20, status date 2004-10-13, 4 hours a day, A marks actual dates.
Project Planning Timeline
Nuclear Monkey Software

## Calendars

- Standard: Mon-Fri 10:00-12:00, 13:00-20:00; Sat-Sun off. Exceptions (off unless hours are given): 2004-11-11, 2004-11-25 to 2004-11-28, 2004-12-15 08:00-12:00, 13:00-17:00, 2004-12-16 to 2004-12-17, 2004-12-20 to 2004-12-24, 2004-12-27 to 2004-12-31, 2005-01-03 to 2005-01-07, 2005-01-17, 2005-02-03, 2005-02-21, 2005-03-21 to 2005-03-25.

## Resources

| Resource | Group |
| --- | --- |
| Garret Rickey | Programmer |
| Jeep Barnett | Programmer |
| Dave Kircher | Programmer |
| Kim Swift | Programmer |
| Scott Klintworth | Artist |
| Eric Brown | Artist |
| Realm Lovejoy | Artist |
| Paul Graham | Artist |
| Spiffy McGee |  |

## Schedule

| ID | WBS | Task | Type | Duration | Start | Finish | Predecessors | Total slack | Constraint | Resources | Work |
| --- | --- | --- | --- | --- | --- | --- | --- | --- | --- | --- | --- |
| 1 | 1 | First Engine Proof | milestone | 0d | 2004-11-19 | 2004-11-19 |  | 183.75d | start no earlier than 2004-11-19 |  |  |
| 2 | 2 | First Playable | milestone | 0d | 2004-12-10 | 2004-12-10 | 1 | 154.5d | start no earlier than 2004-12-10 |  |  |
| 3 | 3 | Pre-alpha | milestone | 0d | 2005-02-08 | 2005-02-08 | 2 | 0d | must finish on 2005-02-08 |  |  |
| 4 | 4 | Alpha | milestone | 0d | 2005-03-15 | 2005-03-15 | 3 | 0d | must finish on 2005-03-15 |  |  |
| 5 | 5 | Beta | milestone | 0d | 2005-04-06 | 2005-04-06 | 4 | 0d | must finish on 2005-04-06 |  |  |
| 6 | 6 | Gold | milestone | 0d | 2005-04-20 | 2005-04-20 | 5 | 0d | must finish on 2005-04-20 |  |  |
| 7 | 7 | **General Engine Tasks** |  | 158.75d? | 2004-10-11 | 2005-02-16 |  | 87.75d |  |  | 2082h |
| 8 | 7.1 | **AI StateMachine** |  | 17.25d? | 2004-10-11 | 2004-10-20 |  | 229.25d |  | Kim Swift | 138h |
| 9 | 7.1.1 | Complete Base Classes |  | 17.25d? | 2004-10-11 | 2004-10-20 |  | 229.25d | start no earlier than 2004-10-11 | Kim Swift | 69h |
| 10 | 7.2 | **In-Game Text Object** |  | 8.25d? | 2004-10-20 | 2004-10-25 |  | 222.5d |  | Jeep Barnett | 66h |
| 11 | 7.2.1 | Text Interface |  | 8.25d? | 2004-10-20 | 2004-10-25 |  | 222.5d | finish no earlier than 2004-10-25 | Jeep Barnett | 33h |
| 12 | 7.3 | **Bump Mapping** |  | 21.75d? | 2005-01-18 | 2005-01-31 |  | 112.5d |  | Dave Kircher | 174h |
| 13 | 7.3.1 | Test and refine |  | 21.75d? | 2005-01-18 | 2005-01-31 |  | 112.5d | finish no earlier than 2005-01-31 | Dave Kircher | 87h |
| 14 | 7.4 | **Particle System** |  | 37.5d? | 2004-11-17 | 2004-12-13 |  | 150.5d |  | Dave Kircher | 306h |
| 15 | 7.4.1 | System |  | 12.75d? | 2004-11-17 | 2004-11-24 |  | 175.25d | finish no earlier than 2004-11-24 | Dave Kircher | 51h |
| 16 | 7.4.2 | Lava Steam |  | 3.75d? | 2004-11-24 | 2004-11-29 |  | 173d | finish no earlier than 2004-11-29 | Dave Kircher | 15h |
| 17 | 7.4.3 | Fireballs |  | 8.25d? | 2004-12-01 | 2004-12-06 |  | 161.75d | finish no earlier than 2004-12-06 | Dave Kircher | 33h |
| 18 | 7.4.4 | Dust |  | 6d? | 2004-12-06 | 2004-12-08 |  | 157.25d | finish no earlier than 2004-12-08 | Dave Kircher | 24h |
| 19 | 7.4.5 | Torch Lights |  | 8.25d? | 2004-12-08 | 2004-12-13 |  | 150.5d | finish no earlier than 2004-12-13 | Dave Kircher | 33h |
| 20 | 7.5 | **Matrix Buddy Additions** |  | 19.5d? | 2004-10-22 | 2004-11-03 |  | 206.75d |  | Dave Kircher | 156h |
| 21 | 7.5.1 | Clone Matrix Buddy |  | 19.5d? | 2004-10-22 | 2004-11-03 |  | 206.75d | finish no earlier than 2004-11-03 | Dave Kircher | 78h |
| 22 | 7.6 | **Animated Meshes** |  | 60d? | 2004-10-11 | 2004-11-17 |  | 186.5d |  | Dave Kircher | 717h |
| 23 | 7.6.1 | Optimize (vertex blending) and Test |  | 24d? | 2004-10-11 | 2004-10-25 |  | 222.5d | finish no earlier than 2004-10-25 | Dave Kircher | 96h |
| 24 | 7.6.2 | Importing artist's work |  | 44.25d? | 2004-10-20 | 2004-11-17 |  | 186.5d | finish no earlier than 2004-11-17 | Dave Kircher | 177h |
| 25 | 7.6.3 | Making it easily accesible |  | 51d? | 2004-10-11 | 2004-11-10 |  | 195.5d | start no earlier than 2004-10-11 | Dave Kircher | 204h |

| ID | WBS | Task | Duration | Start | Finish | Total slack | Constraint | Resources | Work |
| --- | --- | --- | --- | --- | --- | --- | --- | --- | --- |
| 26 | 7.7 | **Physics** | 158.75d? | 2004-10-11 | 2005-02-16 | 87.75d |  |  | 156h |
| 27 | 7.7.1 | Fix physics | 17.25d? | 2004-10-11 | 2004-10-20 | 229.25d | start no earlier than 2004-10-11 |  |  |
| 28 | 7.7.2 | Rigid Body (Lava) | 21.75d? | 2005-01-10 | 2005-01-24 | 123.75d | finish no earlier than 2005-01-24 | Jeep Barnett | 87h |
| 29 | 7.7.3 | Rotational Inertia | 17.25d? | 2005-02-07 | 2005-02-16 | 87.75d | finish no earlier than 2005-02-16 | Kim Swift | 69h |
| 30 | 7.8 | **Portal System** | 44.62d? | 2004-11-09 | 2004-12-10 | 152.75d |  |  | 369h |
| 31 | 7.8.1 | Partially Working | 10.88d? | 2004-11-09 | 2004-11-17 | 186.5d | finish no earlier than 2004-11-17 | Jeep Barnett; Dave Kircher | 87h |
| 32 | 7.8.2 | Fully Working | 17.62d? | 2004-11-30 | 2004-12-10 | 152.75d | finish no earlier than 2004-12-10 | Dave Kircher; Jeep Barnett | 141h |
| 33 | 7.8.3 | Physics | 35.25d? | 2004-11-17 | 2004-12-10 | 152.75d | finish no earlier than 2004-12-10 | Jeep Barnett | 141h |
| 34 | 8 | **Game Objects** | 179d? | 2004-10-11 | 2005-03-02 | 67.5d |  |  | 4208.04h |
| 35 | 8.1 | **No-Knees Object** | 89.25d? | 2004-10-11 | 2004-12-08 | 157.25d |  | Garret Rickey | 685h |
| 36 | 8.1.1 | **Player Controls** | 6d? | 2004-10-11 | 2004-10-13 | 240.5d |  | Garret Rickey | 72h |
| 37 | 8.1.1.1 | Keyboard Controls | 6d? | 2004-10-11 | 2004-10-13 | 240.5d | start no earlier than 2004-10-11 | Garret Rickey | 24h |
| 38 | 8.1.1.2 | Mouse Controls | 6d? | 2004-10-11 | 2004-10-13 | 240.5d | start no earlier than 2004-10-11 | Garret Rickey | 24h |
| 39 | 8.1.2 | **State Machine** | 12.75d? | 2004-11-15 | 2004-11-22 | 179.75d |  | Garret Rickey | 153h |
| 40 | 8.1.2.1 | Falling | 12.75d? | 2004-11-15 | 2004-11-22 | 179.75d | finish no earlier than 2004-11-22 | Garret Rickey | 51h |
| 41 | 8.1.2.2 | Alignment Through Portals | 12.75d? | 2004-11-15 | 2004-11-22 | 179.75d | finish no earlier than 2004-11-22 | Garret Rickey | 51h |
| 42 | 8.1.3 | Attatch Death Conditions | 3.75d? | 2004-11-22 | 2004-11-23 | 177.5d | finish no earlier than 2004-11-23 | Garret Rickey | 15h |
| 43 | 8.1.4 | Attatch sound effects | 8.25d? | 2004-11-24 | 2004-12-01 | 168.5d | finish no earlier than 2004-12-01 | Garret Rickey | 33h |
| 44 | 8.1.5 | Attatch physics | 12.75d? | 2004-12-01 | 2004-12-08 | 157.25d | finish no earlier than 2004-12-08 | Garret Rickey | 51h |
| 45 | 8.1.6 | Attatch collision | 1d? | 2004-12-08 | 2004-12-08 | 157.75d | start no earlier than 2004-12-08 | Garret Rickey | 4h |
| 46 | 8.2 | **Impy Object** | 33d? | 2004-10-18 | 2004-11-05 | 202.25d |  | Kim Swift | 597.04h |
| 47 | 8.2.1 | **Artificial Intelligence** | 31.13d? | 2004-10-18 | 2004-11-04 | 204.12d |  | Kim Swift | 249.04h |
| 48 | 8.2.1.1 | Implement State Machine | 31.13d? | 2004-10-18 | 2004-11-04 | 204.12d | start no earlier than 2004-10-18 | Kim Swift | 124.52h |
| 49 | 8.2.2 | Attatch sound effects | 12.75d? | 2004-10-27 | 2004-11-03 | 206.75d | finish no earlier than 2004-11-03 | Kim Swift | 51h |
| 50 | 8.2.3 | Attatch physics | 17.25d? | 2004-10-25 | 2004-11-03 | 206.75d | finish no earlier than 2004-11-03 | Kim Swift | 69h |
| 51 | 8.2.4 | Attatch collision | 24d? | 2004-10-22 | 2004-11-05 | 202.25d | start no earlier than 2004-10-22 | Kim Swift | 96h |

| ID | WBS | Task | Duration | Start | Finish | Total slack | Constraint | Resources | Work |
| --- | --- | --- | --- | --- | --- | --- | --- | --- | --- |
| 52 | 8.3 | **Demon Object** | 42d? | 2005-01-10 | 2005-02-07 | 103.5d |  | Kim Swift | 576h |
| 53 | 8.3.1 | **Artificial Intelligence** | 42d? | 2005-01-10 | 2005-02-07 | 103.5d |  | Kim Swift | 336h |
| 54 | 8.3.1.1 | Implement State Machine | 42d? | 2005-01-10 | 2005-02-07 | 103.5d | finish no earlier than 2005-02-07 | Kim Swift | 168h |
| 55 | 8.3.2 | Attatch sound effects | 6d? | 2005-01-26 | 2005-01-28 | 114.75d | finish no earlier than 2005-01-28 | Kim Swift | 24h |
| 56 | 8.3.3 | Attatch physics | 6d? | 2005-01-31 | 2005-02-02 | 108d | finish no earlier than 2005-02-02 | Kim Swift | 24h |
| 57 | 8.3.4 | Attatch collision | 6d? | 2005-02-02 | 2005-02-07 | 103.5d | finish no earlier than 2005-02-07 | Kim Swift | 24h |
| 58 | 8.4 | **Lava Turtle Object** | 17.25d? | 2004-12-06 | 2004-12-15 | 145.5d |  | Kim Swift | 205h |
| 59 | 8.4.1 | **Artificial Intelligence** | 10d? | 2004-12-06 | 2004-12-10 | 152.75d |  | Kim Swift | 80h |
| 60 | 8.4.1.1 | Implement State Machine | 10d? | 2004-12-06 | 2004-12-10 | 152.75d | finish no earlier than 2004-12-10 | Kim Swift | 40h |
| 61 | 8.4.2 | Attatch sound effects | 1d? | 2004-12-13 | 2004-12-13 | 151d | start no earlier than 2004-12-13 | Kim Swift | 4h |
| 62 | 8.4.3 | Attatch physics | 6.5d? | 2004-12-13 | 2004-12-15 | 145.5d | finish no earlier than 2004-12-15 | Kim Swift | 26h |
| 63 | 8.4.4 | Attatch collision | 6.5d? | 2004-12-13 | 2004-12-15 | 145.5d | finish no earlier than 2004-12-15 | Kim Swift | 26h |
| 64 | 8.5 | **Wally Object** | 42d? | 2004-11-04 | 2004-12-03 | 164d |  |  | 514h |
| 65 | 8.5.1 | **Artificial Intelligence** | 37.5d? | 2004-11-08 | 2004-12-03 | 164d |  | Kim Swift | 312h |
| 66 | 8.5.1.1 | Implement State Machine | 10.5d? | 2004-11-29 | 2004-12-03 | 164d | finish no earlier than 2004-12-03 | Kim Swift | 42h |
| 67 | 8.5.1.2 | Implement system to create help sequences | 21.75d? | 2004-11-08 | 2004-11-22 | 179.75d | finish no earlier than 2004-11-22 | Kim Swift | 87h |
| 68 | 8.5.1.3 | Script help sequences | 8.25d? | 2004-11-22 | 2004-11-29 | 173d | finish no earlier than 2004-11-29 | Kim Swift | 33h |
| 69 | 8.5.2 | **Attatch sounds** | 21.75d? | 2004-11-04 | 2004-11-18 | 184.25d |  | Jeep Barnett | 178h |
| 70 | 8.5.2.1 | Sound Effects | 1d? | 2004-11-04 | 2004-11-04 | 205d | start no earlier than 2004-11-04 | Jeep Barnett | 4h |
| 71 | 8.5.2.2 | Voice Synth | 21.75d? | 2004-11-04 | 2004-11-18 | 184.25d | start no earlier than 2004-11-04 | Jeep Barnett | 87h |
| 72 | 8.5.3 | Attatch potal technology | 6d? | 2004-11-22 | 2004-11-24 | 175.25d | finish no earlier than 2004-11-24 | Dave Kircher | 24h |
| 73 | 8.6 | **Camera Object** | 21.75d? | 2004-10-11 | 2004-10-22 | 224.75d |  | Garret Rickey | 180h |
| 74 | 8.6.1 | Attatch collision | 17.25d? | 2004-10-13 | 2004-10-22 | 224.75d | finish no earlier than 2004-10-22 | Garret Rickey | 69h |
| 75 | 8.6.2 | Camera Modes | 6d? | 2004-10-11 | 2004-10-13 | 240.5d | finish no earlier than 2004-10-13 | Garret Rickey | 24h |

| ID | WBS | Task | Duration | Start | Finish | Total slack | Constraint | Resources | Work |
| --- | --- | --- | --- | --- | --- | --- | --- | --- | --- |
| 76 | 8.7 | **Boulder Object** | 21.75d? | 2004-11-01 | 2004-11-15 | 191d |  | Garret Rickey | 261h |
| 77 | 8.7.1 | Attatch collision | 21.75d? | 2004-11-01 | 2004-11-15 | 191d | finish no earlier than 2004-11-15 | Garret Rickey | 87h |
| 78 | 8.7.2 | Attatch physics | 21.75d? | 2004-11-01 | 2004-11-15 | 191d | finish no earlier than 2004-11-15 | Garret Rickey | 87h |
| 79 | 8.8 | **Box Object** | 21.75d? | 2005-02-16 | 2005-03-02 | 67.5d |  | Jeep Barnett | 174h |
| 80 | 8.8.1 | Box Improvements | 21.75d? | 2005-02-16 | 2005-03-02 | 67.5d | finish no earlier than 2005-03-02 | Jeep Barnett | 87h |
| 81 | 8.9 | **Button Object** | 12.75d? | 2004-11-17 | 2004-11-24 | 175.25d |  | Jeep Barnett | 139h |
| 82 | 8.9.1 | Attatch sound effects | 1d? | 2004-11-23 | 2004-11-23 | 178d | start no earlier than 2004-11-23 | Jeep Barnett | 4h |
| 83 | 8.9.2 | Attatch collision | 8.25d? | 2004-11-17 | 2004-11-22 | 179.75d | finish no earlier than 2004-11-22 | Jeep Barnett | 33h |
| 84 | 8.9.3 | Depression conditions | 12.75d? | 2004-11-17 | 2004-11-24 | 175.25d | finish no earlier than 2004-11-24 | Jeep Barnett | 51h |
| 85 | 8.10 | **Lava Object** | 39.75d? | 2005-01-10 | 2005-02-04 | 105.75d |  | Jeep Barnett | 348h |
| 86 | 8.10.1 | Attatch sound effects | 6d? | 2005-01-26 | 2005-01-28 | 114.75d | finish no earlier than 2005-01-28 | Jeep Barnett | 24h |
| 87 | 8.10.2 | Create physics | 21.75d? | 2005-01-10 | 2005-01-24 | 123.75d | finish no earlier than 2005-01-24 | Jeep Barnett | 87h |
| 88 | 8.10.3 | Attatch collision | 19.5d? | 2005-01-24 | 2005-02-04 | 105.75d | finish no earlier than 2005-02-04 | Jeep Barnett | 78h |
| 89 | 8.11 | **Portal Object** | 39.75d? | 2004-11-10 | 2004-12-08 | 157.25d |  |  | 183h |
| 90 | 8.11.1 | Attatch sound effects | 6d? | 2004-11-22 | 2004-11-24 | 175.25d | finish no earlier than 2004-11-24 | Jeep Barnett | 24h |
| 91 | 8.11.2 | Attatch collision | 39.75d? | 2004-11-10 | 2004-12-08 | 157.25d | finish no earlier than 2004-12-08 | Jeep Barnett | 159h |
| 92 | 8.12 | **Torch Object** | 12.75d? | 2005-02-07 | 2005-02-14 | 92.25d |  | Jeep Barnett | 153h |
| 93 | 8.12.1 | Attatch sound effects | 12.75d? | 2005-02-07 | 2005-02-14 | 92.25d | finish no earlier than 2005-02-14 | Jeep Barnett | 51h |
| 94 | 8.12.2 | Attatch collision | 12.75d? | 2005-02-07 | 2005-02-14 | 92.25d | finish no earlier than 2005-02-14 | Jeep Barnett | 51h |
| 95 | 8.13 | **Door Object** | 24d? | 2004-10-20 | 2004-11-03 | 206.75d |  | Jeep Barnett | 193h |
| 96 | 8.13.1 | Attatch sound effects | 1d? | 2004-10-29 | 2004-10-29 | 214d | start no earlier than 2004-10-29 | Jeep Barnett | 4h |
| 97 | 8.13.2 | Loading Levels | 17.25d? | 2004-10-20 | 2004-10-29 | 213.5d | finish no earlier than 2004-10-29 | Jeep Barnett | 69h |
| 98 | 8.13.3 | Attatch collision | 6d? | 2004-11-01 | 2004-11-03 | 206.75d | finish no earlier than 2004-11-03 | Jeep Barnett | 24h |
| 99 | 9 | **Game Levels** | 237.5d? | 2004-10-13 | 2005-04-18 | 4.5d |  |  | 1191h |
| 100 | 9.1 | **Level One: Polishing Up** | 40.5d? | 2004-10-13 | 2004-11-05 | 201.5d |  |  | 156h |
| 101 | 9.1.1 | Build WorldCraft Level | 12.75d? | 2004-10-25 | 2004-11-01 | 211.25d | finish no earlier than 2004-11-01 | Garret Rickey | 51h |
| 102 | 9.1.2 | BSP Tree | 17.25d? | 2004-10-13 | 2004-10-22 | 224.75d | start no earlier than 2004-10-13 | Garret Rickey | 69h |
| 103 | 9.1.3 | Register AI Information | 6.75d? | 2004-11-03 | 2004-11-05 | 201.5d | start no earlier than 2004-11-03 | Kim Swift | 27h |
| 104 | 9.1.4 | Win Conditions | 2.25d? | 2004-11-02 | 2004-11-02 | 208.25d | start no earlier than 2004-11-02 | Garret Rickey | 9h |

| ID | WBS | Task | Duration | Start | Finish | Total slack | Constraint | Resources | Work |
| --- | --- | --- | --- | --- | --- | --- | --- | --- | --- |
| 105 | 9.2 | **Level Two: Boulder Dash** | 38.25d? | 2005-01-27 | 2005-02-23 | 78.75d |  |  | 207h |
| 106 | 9.2.1 | Build WorldCraft Level | 18d? | 2005-01-27 | 2005-02-09 | 99d | finish no earlier than 2005-02-09 | Garret Rickey | 72h |
| 107 | 9.2.2 | BSP Tree | 12.75d? | 2005-02-09 | 2005-02-16 | 87.75d | finish no earlier than 2005-02-16 | Garret Rickey | 51h |
| 108 | 9.2.3 | Register AI Information | 10.5d? | 2005-02-16 | 2005-02-23 | 78.75d | finish no earlier than 2005-02-23 | Kim Swift | 42h |
| 109 | 9.2.4 | Win Conditions | 10.5d? | 2005-02-16 | 2005-02-23 | 78.75d | finish no earlier than 2005-02-23 | Garret Rickey | 42h |
| 110 | 9.3 | **Level Three: Hallway to Hell** | 44.25d? | 2005-02-16 | 2005-03-16 | 45d |  |  | 231h |
| 111 | 9.3.1 | Build WorldCraft Level | 17.25d? | 2005-02-16 | 2005-02-28 | 72d | finish no earlier than 2005-02-28 | Dave Kircher | 69h |
| 112 | 9.3.2 | BSP Tree | 15d? | 2005-03-01 | 2005-03-09 | 56.25d | finish no earlier than 2005-03-09 | Dave Kircher | 60h |
| 113 | 9.3.3 | Register AI Information | 12.75d? | 2005-03-02 | 2005-03-09 | 56.25d | finish no earlier than 2005-03-09 | Kim Swift | 51h |
| 114 | 9.3.4 | Win Conditions | 12.75d? | 2005-03-09 | 2005-03-16 | 45d | finish no earlier than 2005-03-16 | Dave Kircher | 51h |
| 115 | 9.4 | **Level Four: Beware of Falling Rocks** | 35.25d? | 2005-03-28 | 2005-04-18 | 4.5d |  |  | 204h |
| 116 | 9.4.1 | Build WorldCraft Level | 12.75d? | 2005-03-28 | 2005-04-04 | 27d | finish no earlier than 2005-04-04 | Jeep Barnett | 51h |
| 117 | 9.4.2 | BSP Tree | 12.75d? | 2005-04-04 | 2005-04-11 | 15.75d | finish no earlier than 2005-04-11 | Jeep Barnett | 51h |
| 118 | 9.4.3 | Register AI Information | 12.75d? | 2005-04-04 | 2005-04-11 | 15.75d | finish no earlier than 2005-04-11 | Kim Swift | 51h |
| 119 | 9.4.4 | Win Conditions | 12.75d? | 2005-04-11 | 2005-04-18 | 4.5d | finish no earlier than 2005-04-18 | Jeep Barnett | 51h |
| 120 | 9.5 | **Level Five: Fire with Fire** | 33d? | 2005-01-10 | 2005-01-31 | 112.5d |  |  | 255h |
| 121 | 9.5.1 | Build WorldCraft Level | 15d? | 2005-01-10 | 2005-01-19 | 130.5d | finish no earlier than 2005-01-19 | Garret Rickey | 60h |
| 122 | 9.5.2 | BSP Tree | 12.75d? | 2005-01-18 | 2005-01-25 | 121.5d | finish no earlier than 2005-01-25 | Garret Rickey | 51h |
| 123 | 9.5.3 | Register AI Information | 10.5d? | 2005-01-24 | 2005-01-28 | 114.75d | finish no earlier than 2005-01-28 | Kim Swift | 42h |
| 124 | 9.5.4 | Event Triggers | 15d? | 2005-01-18 | 2005-01-26 | 119.25d | finish no earlier than 2005-01-26 | Garret Rickey | 60h |
| 125 | 9.5.5 | Win Conditions | 10.5d? | 2005-01-25 | 2005-01-31 | 112.5d | finish no earlier than 2005-01-31 | Garret Rickey | 42h |
| 126 | 9.6 | **Artist's Playroom** | 17.25d? | 2004-12-03 | 2004-12-14 | 148.25d |  | Garret Rickey | 138h |
| 127 | 9.6.1 | Build WorldCraft Level | 17.25d? | 2004-12-03 | 2004-12-14 | 148.25d | start no earlier than 2004-12-03 | Garret Rickey | 69h |
| 128 | 10 | **Menus** | 37.25d? | 2004-12-01 | 2005-01-18 | 132.75d |  | Dave Kircher | 300h |
| 129 | 10.1 | **3D Menus** | 12.75d? | 2005-01-10 | 2005-01-18 | 132.75d |  |  | 51h |
| 130 | 10.1.1 | Level Selection | 12.75d? | 2005-01-10 | 2005-01-18 | 132.75d | finish no earlier than 2005-01-18 | Dave Kircher | 51h |

| ID | WBS | Task | Duration | Start | Finish | Complete | Remaining | Total slack | Constraint | Resources | Work | Actual work |
| --- | --- | --- | --- | --- | --- | --- | --- | --- | --- | --- | --- | --- |
| 131 | 10.2 | **2D Menus** | 24.5d? | 2004-12-01 | 2004-12-15 |  |  | 145.5d |  |  | 100h |  |
| 132 | 10.2.1 | Main Menu | 12.75d? | 2004-12-01 | 2004-12-08 |  |  | 157.25d | finish no earlier than 2004-12-08 | Dave Kircher | 51h |  |
| 133 | 10.2.2 | Options Menu | 8.25d? | 2004-12-08 | 2004-12-13 |  |  | 150.5d | finish no earlier than 2004-12-13 | Dave Kircher | 33h |  |
| 134 | 10.2.3 | Pause Menu | 4d? | 2004-12-14 | 2004-12-15 |  |  | 145.5d | finish no earlier than 2004-12-15 | Dave Kircher | 16h |  |
| 135 | 11 | **Game Wrap-Up** | 12.75d? | 2005-04-04 | 2005-04-11 |  |  | 15.75d |  |  | 153h |  |
| 136 | 11.1 | Game Installer | 12.75d? | 2005-04-04 | 2005-04-11 |  |  | 15.75d | finish no earlier than 2005-04-11 | Dave Kircher | 51h |  |
| 137 | 11.2 | Intro Screens | 12.75d? | 2005-04-04 | 2005-04-11 |  |  | 15.75d | start no earlier than 2005-04-04 | Kim Swift | 51h |  |
| 138 | 11.3 | Credits Sequence | 12.75d? | 2005-04-04 | 2005-04-11 |  |  | 15.75d | finish no earlier than 2005-04-11 | Spiffy McGee | 51h |  |
| 139 | 12 | **Sounds** | 44.25d? | 2005-02-14 | 2005-03-14 |  |  | 49.5d |  | Jeep Barnett | 531h |  |
| 140 | 12.1 | Sound Effects | 44.25d? | 2005-02-14 | 2005-03-14 |  |  | 49.5d | finish no earlier than 2005-03-14 | Jeep Barnett | 177h |  |
| 141 | 12.2 | Music | 44.25d? | 2005-02-14 | 2005-03-14 |  |  | 49.5d | finish no earlier than 2005-03-14 | Jeep Barnett | 177h |  |
| 142 | 13 | **Marketing Materials** | 28.5d? | 2005-04-04 | 2005-04-20 |  |  | 0d |  | Jeep Barnett | 342h |  |
| 143 | 13.1 | Box Cover | 28.5d? | 2005-04-04 | 2005-04-20 |  |  | 0d | finish no earlier than 2005-04-20 | Jeep Barnett | 114h |  |
| 144 | 13.2 | Manual | 28.5d? | 2005-04-04 | 2005-04-20 |  |  | 0d | finish no earlier than 2005-04-20 | Jeep Barnett | 114h |  |
| 145 | 14 | **Art Assets** | 71.25d? | 2004-10-11 A | 2004-11-24 |  | 70.99d? | 175.25d |  |  | 1773h | 6h |
| 146 | 14.1 | **No-Knees** | 71.25d? | 2004-10-11 A | 2004-11-24 | 2% | 70.01d? | 175.25d |  |  | 495h | 6h |
| 147 | 14.1.1 | Model | 12.75d? | 2004-10-11 | 2004-10-18 |  |  | 233.75d | finish no earlier than 2004-10-18 | Scott Klintworth | 51h |  |
| 148 | 14.1.2 | ROM | 12.75d? | 2004-10-22 | 2004-10-29 |  |  | 213.5d | start no earlier than 2004-10-22 | Eric Brown | 51h |  |
| 149 | 14.1.3 | Rigging | 10.5d? | 2004-10-18 A | 2004-10-22 | 14% | 9d? | 224.75d | finish no earlier than 2004-10-22 | Eric Brown | 42h | 6h |
| 150 | 14.1.4 | Textures | 12.75d? | 2004-10-22 | 2004-10-29 |  |  | 213.5d | finish no earlier than 2004-10-29 | Realm Lovejoy | 51h |  |
| 151 | 14.1.5 | Animations | 37.5d? | 2004-11-01 | 2004-11-24 |  |  | 175.25d | finish no earlier than 2004-11-24 | Eric Brown; Paul Graham | 300h |  |
| 152 | 14.2 | **Impy** | 55.5d? | 2004-10-11 | 2004-11-15 |  |  | 191d |  |  | 282h |  |
| 153 | 14.2.1 | Model | 6d? | 2004-10-11 | 2004-10-13 |  |  | 240.5d | start no earlier than 2004-10-11 | Paul Graham | 24h |  |
| 154 | 14.2.2 | ROM | 10.5d? | 2004-10-18 | 2004-10-22 |  |  | 224.75d | finish no earlier than 2004-10-22 | Paul Graham | 42h |  |
| 155 | 14.2.3 | Rigging | 8.25d? | 2004-10-13 | 2004-10-18 |  |  | 233.75d | finish no earlier than 2004-10-18 | Paul Graham | 33h |  |
| 156 | 14.2.4 | Textures | 12.75d? | 2004-10-18 | 2004-10-25 |  |  | 222.5d | finish no earlier than 2004-10-25 | Realm Lovejoy | 51h |  |
| 157 | 14.2.5 | Animations | 33d? | 2004-10-25 | 2004-11-15 |  |  | 191d | finish no earlier than 2004-11-15 | Paul Graham | 132h |  |

| ID | WBS | Task | Type | Duration | Start | Finish | Total slack | Constraint | Resources | Work |
| --- | --- | --- | --- | --- | --- | --- | --- | --- | --- | --- |
| 158 | 14.3 | **Demon** |  | 55.5d? | 2004-10-11 | 2004-11-15 | 191d |  |  | 300h |
| 159 | 14.3.1 | Model |  | 6d? | 2004-10-11 | 2004-10-13 | 240.5d | finish no earlier than 2004-10-13 | Scott Klintworth | 24h |
| 160 | 14.3.2 | ROM |  | 10.5d? | 2004-10-18 | 2004-10-22 | 224.75d | finish no earlier than 2004-10-22 | Scott Klintworth | 42h |
| 161 | 14.3.3 | Rigging |  | 12.75d? | 2004-10-13 | 2004-10-20 | 229.25d | finish no earlier than 2004-10-20 | Scott Klintworth | 51h |
| 162 | 14.3.4 | Textures |  | 12.75d? | 2004-10-13 | 2004-10-20 | 229.25d | finish no earlier than 2004-10-20 | Realm Lovejoy | 51h |
| 163 | 14.3.5 | Animations |  | 33d? | 2004-10-25 | 2004-11-15 | 191d | finish no earlier than 2004-11-15 | Scott Klintworth | 132h |
| 164 | 14.4 | **Lava Turtle** |  | 55.5d? | 2004-10-11 | 2004-11-15 | 191d |  |  | 210h |
| 165 | 14.4.1 | Model |  | 6d? | 2004-10-11 | 2004-10-13 | 240.5d | start no earlier than 2004-10-11 | Realm Lovejoy | 24h |
| 166 | 14.4.2 | ROM |  | 10.5d? | 2004-10-18 | 2004-10-22 | 224.75d | finish no earlier than 2004-10-22 | Scott Klintworth | 42h |
| 167 | 14.4.3 | Rigging |  | 12.75d? | 2004-10-13 | 2004-10-20 | 229.25d | finish no earlier than 2004-10-20 | Eric Brown | 51h |
| 168 | 14.4.4 | Textures |  | 12.75d? | 2004-11-01 | 2004-11-08 | 200d | finish no earlier than 2004-11-08 | Realm Lovejoy | 51h |
| 169 | 14.4.5 | Animations |  | 10.5d? | 2004-11-08 | 2004-11-15 | 191d | finish no earlier than 2004-11-15 | Scott Klintworth | 42h |
| 170 | 14.5 | **Wally** |  | 46.5d? | 2004-10-11 | 2004-11-08 | 200d |  |  | 108h |
| 171 | 14.5.1 | Model |  | 6d? | 2004-10-11 | 2004-10-13 | 240.5d | start no earlier than 2004-10-11 | Realm Lovejoy | 24h |
| 172 | 14.5.2 | Rigging |  | 8.25d? | 2004-10-13 | 2004-10-18 | 233.75d | finish no earlier than 2004-10-18 | Eric Brown | 33h |
| 173 | 14.5.3 | Textures |  | 12.75d? | 2004-11-01 | 2004-11-08 | 200d | finish no earlier than 2004-11-08 | Eric Brown | 51h |
| 174 | 14.6 | **Torch** |  | 10.5d? | 2004-11-08 | 2004-11-15 | 191d |  |  | 84h |
| 175 | 14.6.1 | Model |  | 10.5d? | 2004-11-08 | 2004-11-15 | 191d | finish no earlier than 2004-11-15 | Realm Lovejoy | 42h |
| 176 | 14.6.2 | Texture |  | 10.5d? | 2004-11-08 | 2004-11-15 | 191d | finish no earlier than 2004-11-15 | Realm Lovejoy | 42h |
| 177 | 14.7 | **Boulder** |  | 0d | 2004-10-11 | 2004-10-11 | 246.5d |  |  |  |
| 178 | 14.7.1 | Model | milestone | 0d | 2004-10-11 | 2004-10-11 | 246.5d |  | Scott Klintworth |  |
| 179 | 14.7.2 | Texture | milestone | 0d | 2004-10-11 | 2004-10-11 | 246.5d |  | Scott Klintworth |  |
| 180 | 14.8 | **Box** |  | 12.75d? | 2004-11-01 | 2004-11-08 | 200d |  |  | 102h |
| 181 | 14.8.1 | Model |  | 12.75d? | 2004-11-01 | 2004-11-08 | 200d | start no earlier than 2004-11-01 | Realm Lovejoy | 51h |
| 182 | 14.8.2 | Texture |  | 12.75d? | 2004-11-01 | 2004-11-08 | 200d | finish no earlier than 2004-11-08 | Realm Lovejoy | 51h |

| ID | WBS | Task | Duration | Start | Finish | Total slack | Constraint | Resources | Work |
| --- | --- | --- | --- | --- | --- | --- | --- | --- | --- |
| 183 | 14.9 | **Button** | 17.25d? | 2004-11-15 | 2004-11-24 | 175.25d |  |  | 138h |
| 184 | 14.9.1 | Model | 17.25d? | 2004-11-15 | 2004-11-24 | 175.25d | finish no earlier than 2004-11-24 | Realm Lovejoy | 69h |
| 185 | 14.9.2 | Texture | 17.25d? | 2004-11-15 | 2004-11-24 | 175.25d | finish no earlier than 2004-11-24 | Realm Lovejoy | 69h |
| 186 | 14.10 | **Enironment** | 13.5d? | 2004-10-11 | 2004-10-18 | 233d |  |  | 54h |
| 187 | 14.10.1 | Textures | 13.5d? | 2004-10-11 | 2004-10-18 | 233d |  | Eric Brown | 54h |
